# ProcessAssets Implemenation Plan

Schedule from MS Project, 2002-11-04 to 2004-01-28, status date 2002-11-04.
Project KikStart
PEP, Inc.

## Calendars

- Standard: Mon-Fri 08:00-12:00, 13:00-17:00; Sat-Sun off.

## Resources

| Resource |
| --- |
| Mark Goldin |
| Mark Rabideau |
| Adina Kram |
| Bruce McNaughton |
| Kenneth Borrowdale |
| Kevin Boyle |
| Alan Boval |
| Gary Reissman |
| Dan O'day |
| David Roth |
| Maggie Nelson |
| Garvin Fouts |
| Patti Goettel |
| Christopher Dean |

## Schedule

| ID | WBS | Task | Duration | Start | Finish | Predecessors | Total slack | Free slack | Constraint |
| --- | --- | --- | --- | --- | --- | --- | --- | --- | --- |
| 1 | 1 | **Phase 1 Initiation Phase** | 39.12d? | 2002-11-04 | 2002-12-27 |  | 0d |  |  |
| 2 | 1.1 | **Initiating a Project** | 6d | 2002-11-04 | 2002-11-11 |  | 0d |  |  |
| 3 | 1.1.1 | Prepare Proj Plan Sect 2.0 (Project Charter and Scope Statement) | 3d | 2002-11-04 | 2002-11-06 |  | 8.88d | 3d |  |
| 4 | 1.1.2 | Prepare Proj Plan Sect 3.0 (Project Organization) | 4d | 2002-11-04 | 2002-11-07 |  | 7.88d | 2d |  |
| 5 | 1.1.3 | Identify and Evaluate Alternative Approaches | 1d | 2002-11-04 | 2002-11-04 |  | 10.88d | 5d |  |
| 6 | 1.1.4 | Start a Risk Log | 2h | 2002-11-04 | 2002-11-04 |  | 11.62d | 5.75d |  |
| 7 | 1.1.5 | Prepare Proj Plan Sect 4.2 (Initiation Phase Plan) | 6d | 2002-11-04 | 2002-11-11 |  | 0d |  |  |
| 8 | 1.2 | Gain Approval of Initiation Phase Plan and Start Project | 1h | 2002-11-12 | 2002-11-12 | 7, 6, 5, 3, 4 | 0d |  |  |
| 9 | 1.3 | WP IP-1 - Identify Requirements | 27.5d? | 2002-11-12 | 2002-12-19 | 8 | 2.5d |  |  |
| 10 | 1.4 | **Planning a Project** | 32d | 2002-11-12 | 2002-12-26 | 8 | 0d |  |  |
| 11 | 1.4.1 | Review & Revise PQP | 2d | 2002-11-12 | 2002-11-14 |  | 31.38d |  |  |
| 12 | 1.4.2 | Prep Overall Project Plan | 30d | 2002-11-12 | 2002-12-24 |  | 0d |  |  |
| 13 | 1.4.3 | Prep Business Case | 3d | 2002-11-12 | 2002-11-15 |  | 30.38d |  |  |
| 14 | 1.4.4 | Setup Project File | 2d | 2002-11-12 | 2002-11-14 |  | 31.38d |  |  |
| 15 | 1.4.5 | Consolidate Project Plan | 2d | 2002-12-24 | 2002-12-26 | 14, 13, 12, 11, 9 | 0d |  |  |
| 16 | 1.5 | **Manage a Phase** | 38.12d? | 2002-11-04 | 2002-12-26 |  | 0d |  |  |
| 17 | 1.5.1 | Executing a Phase | 35d | 2002-11-04 | 2002-12-20 |  | 6.5d |  |  |
| 18 | 1.5.2 | Controlling a Phase | 30d | 2002-11-04 | 2002-12-13 |  | 11.5d |  |  |
| 19 | 1.5.3 | Initiating a Phase | 1d? | 2002-12-13 | 2002-12-16 |  | 0d |  | as late as possible |
| 20 | 1.5.4 | Planning a Phase | 8d | 2002-12-16 | 2002-12-26 | 19 | 0d |  | as late as possible |
| 21 | 1.5.5 | Closing a Phase | 5d | 2002-12-19 | 2002-12-26 |  | 0d |  | as late as possible |
| 22 | 1.6 | Gain Approval to Proceed to Next Phase | 1d? | 2002-12-26 | 2002-12-27 | 15, 16 | 0d |  |  |
| 23 | 2 | **Phase 2 Specification** | 41d? | 2002-12-27 | 2003-02-24 | 22 | 0d |  |  |
| 24 | 2.1 | WP P2-1 - Specify the Solution | 27.5d? | 2002-12-27 | 2003-02-04 |  | 11.5d | 8.5d |  |
| 25 | 2.2 | WP P2-2 - Design the Solution | 36d? | 2002-12-27 | 2003-02-17 |  | 3d | 0d |  |
| 26 | 2.3 | Formal Design Review (Quality Review) | 1d? | 2003-02-17 | 2003-02-18 | 24, 25 | 3d |  |  |

Notes:
- 9: Note: This activity is the first activity of the solution development life cycle. This work is completed in parallel with planning the project. For the definition of this activity see Identify Requirements in the Solution Development Life Cycle.

| ID | WBS | Task | Duration | Start | Finish | Predecessors | Total slack | Free slack | Constraint |
| --- | --- | --- | --- | --- | --- | --- | --- | --- | --- |
| 27 | 2.4 | **Manage a Phase** | 40d? | 2002-12-27 | 2003-02-21 |  | 0d |  |  |
| 28 | 2.4.1 | Executing a Phase | 40d | 2002-12-27 | 2003-02-21 |  | 0d |  |  |
| 29 | 2.4.2 | Controlling a Phase | 40d | 2002-12-27 | 2003-02-21 |  | 0d |  |  |
| 30 | 2.4.3 | Initiating a Phase | 1d? | 2003-02-10 | 2003-02-11 |  | 0d |  | as late as possible |
| 31 | 2.4.4 | Planning a Phase | 8d | 2003-02-11 | 2003-02-21 | 30 | 0d |  | as late as possible |
| 32 | 2.4.5 | Closing a Phase | 5d | 2003-02-14 | 2003-02-21 |  | 0d |  | as late as possible |
| 33 | 2.5 | Gain Approval to Proceed to Next Phase | 1d? | 2003-02-21 | 2003-02-24 | 27, 26 | 0d |  |  |
| 34 | 3 | **Phase 3 Functionality Iteration 1** | 45.88d? | 2003-02-24 | 2003-04-29 | 33 | 0d |  |  |
| 35 | 3.1 | WP P3-1 Development / Test Function 1 | 32.5d? | 2003-02-24 | 2003-04-09 |  | 197.38d | 0d |  |
| 36 | 3.2 | WP P3-2 Development / Test Function 2, 3, 4 | 32.5d? | 2003-02-24 | 2003-04-09 |  | 197.38d | 0d |  |
| 37 | 3.3 | WP P3-3 Documentation | 15d? | 2003-02-24 | 2003-03-17 |  | 214.88d | 17.5d |  |
| 38 | 3.4 | WP P3-4 Test Functionality | 12.5d? | 2003-04-09 | 2003-04-28 | 35, 36, 37 | 197.38d |  |  |
| 39 | 3.5 | **Manage a Phase** | 44.88d? | 2003-02-24 | 2003-04-28 |  | 0d |  |  |
| 40 | 3.5.1 | Executing a Phase | 44.88d? | 2003-02-24 | 2003-04-28 |  | 0d |  |  |
| 41 | 3.5.2 | Controlling a Phase | 44.88d? | 2003-02-24 | 2003-04-28 |  | 0d |  |  |
| 42 | 3.5.3 | Initiating a Phase | 4d | 2003-04-10 | 2003-04-16 |  | 0d |  | as late as possible |
| 43 | 3.5.4 | Planning a Phase | 8d | 2003-04-16 | 2003-04-28 | 42 | 0d |  | as late as possible |
| 44 | 3.5.5 | Closing a Phase | 13d | 2003-04-09 | 2003-04-28 |  | 0d |  | as late as possible |
| 45 | 3.6 | Gain Approval to Proceed to Next Phase | 1d? | 2003-04-28 | 2003-04-29 | 39 | 0d |  |  |
| 46 | 4 | **Phase 4 Functionality Iteration 2** | 107.5d? | 2003-04-29 | 2003-09-25 | 45 | 0d |  |  |
| 47 | 4.1 | WP P4-1 - Specify the Solution (new or revise) | 27.5d? | 2003-04-29 | 2003-06-05 |  | 35d | 0d |  |
| 48 | 4.2 | WP P4-2 - Design the Solution | 36d? | 2003-04-29 | 2003-06-18 |  | 26.5d | 0d |  |
| 49 | 4.3 | WP P4-4 Development / Test Function 5,6 | 32.5d? | 2003-06-05 | 2003-07-22 | 47 | 35d | 8.5d |  |
| 50 | 4.4 | WP P4-5 Development / Test Function 7,8,9 | 32.5d? | 2003-06-18 | 2003-08-01 | 48 | 26.5d | 0d |  |
| 51 | 4.5 | WP P4-6 Documentation | 15d? | 2003-06-05 | 2003-06-26 | 47 | 52.5d | 26d |  |
| 52 | 4.6 | WP P4-7 Test Functionality | 12.5d? | 2003-08-01 | 2003-08-20 | 51, 50, 49 | 26.5d |  |  |

Notes:
- 34: this stage is not defined yet.
- 46: this stage is not defined yet.
- 47: Identify terms that are used in Elite to make it easier for people relate to the content. / make the changes to topics in the help system. / Be very clear on the definition of 'what is a project'
- 48: Refine the list of projects according to the current definition of a project

| ID | WBS | Task | Duration | Start | Finish | Predecessors | Total slack | Free slack | Constraint |
| --- | --- | --- | --- | --- | --- | --- | --- | --- | --- |
| 53 | 4.7 | **Manage a Phase** | 106.5d? | 2003-04-29 | 2003-09-24 |  | 0d |  |  |
| 54 | 4.7.1 | Executing a Phase | 106.5d? | 2003-04-29 | 2003-09-24 |  | 0d |  |  |
| 55 | 4.7.2 | Controlling a Phase | 106.5d? | 2003-04-29 | 2003-09-24 |  | 0d |  |  |
| 56 | 4.7.3 | Initiating a Phase | 2d | 2003-09-10 | 2003-09-12 |  | 0d |  | as late as possible |
| 57 | 4.7.4 | Planning a Phase | 8d | 2003-09-12 | 2003-09-24 | 56 | 0d |  | as late as possible |
| 58 | 4.7.5 | Closing a Phase | 5d | 2003-09-17 | 2003-09-24 |  | 0d |  | as late as possible |
| 59 | 4.8 | Gain Approval to Proceed to Next Phase | 1d? | 2003-09-24 | 2003-09-25 | 53 | 0d |  |  |
| 60 | 5 | **Phase 5 Confirm the Solution meets Requirements** | 53d? | 2003-09-25 | 2003-12-09 | 46 | 0d |  |  |
| 61 | 5.1 | WP P5-1 Acceptance Test 1 | 21d | 2003-09-25 | 2003-10-24 |  | 43d | 0d |  |
| 62 | 5.2 | Evaluate feedback … | 20.5d? | 2003-09-25 | 2003-10-24 |  | 68.5d |  |  |
| 63 | 5.3 | WP P5-2 Beta Iteration 2 | 25d | 2003-10-24 | 2003-11-28 | 61 | 43d |  |  |
| 64 | 5.4 | Evaluate feedback … | 25d? | 2003-10-24 | 2003-11-28 | 61 | 43d |  |  |
| 65 | 5.5 | WP P5-3 Finalise Documentation | 45.5d? | 2003-09-25 | 2003-11-28 |  | 43.5d |  |  |
| 66 | 5.6 | **Manage a Phase** | 52d? | 2003-09-25 | 2003-12-08 |  | 0d |  |  |
| 67 | 5.6.1 | Executing a Phase | 52d? | 2003-09-25 | 2003-12-08 |  | 0d |  |  |
| 68 | 5.6.2 | Controlling a Phase | 52d? | 2003-09-25 | 2003-12-08 |  | 0d |  |  |
| 69 | 5.6.3 | Initiating a Phase | 2d | 2003-11-24 | 2003-11-26 |  | 0d |  | as late as possible |
| 70 | 5.6.4 | Planning a Phase | 8d | 2003-11-26 | 2003-12-08 | 69 | 0d |  | as late as possible |
| 71 | 5.6.5 | Closing a Phase | 5d | 2003-12-01 | 2003-12-08 |  | 0d |  | as late as possible |
| 72 | 5.7 | Gain Approval to Proceed to Next Phase | 1d? | 2003-12-08 | 2003-12-09 | 66 | 0d |  |  |
| 73 | 6 | **Phase 6 Transfer the Solution to the Client** | 36d? | 2003-12-09 | 2004-01-28 | 72 | 0d |  |  |
| 74 | 6.1 | WP P6-1 Build Release | 35d? | 2003-12-09 | 2004-01-27 |  | 0d |  |  |
| 75 | 6.2 | **Manage a Phase** | 35d? | 2003-12-09 | 2004-01-27 |  | 0d |  |  |
| 76 | 6.2.1 | Executing a Phase | 29d? | 2003-12-09 | 2004-01-19 |  | 6d |  |  |
| 77 | 6.2.2 | Controlling a Phase | 29d? | 2003-12-09 | 2004-01-19 |  | 6d |  |  |
| 78 | 6.2.3 | Closing a Project | 35d | 2003-12-09 | 2004-01-27 |  | 0d |  | as late as possible |
| 79 | 6.3 | Confirm Project Closed | 1d? | 2004-01-27 | 2004-01-28 | 75, 74 | 0d |  |  |
