# ProcessAssets Implemenation Plan

Schedule from MS Project, 2002-11-04 to 2003-06-02, status date 2002-11-04.
Project KikStart
PEP, Inc.

## Calendars

- Standard: Mon-Fri 08:00-12:00, 13:00-17:00; Sat-Sun off.

## Resources

| Resource |
| --- |
| Mark Goldin |
| Mark Rabideau |
| Adina Kram |
| Bruce McNaughton |
| Kenneth Borrowdale |
| Kevin Boyle |
| Alan Boval |
| Gary Reissman |
| Dan O'day |
| David Roth |
| Maggie Nelson |
| Garvin Fouts |
| Patti Goettel |
| Christopher Dean |

## Schedule

| ID | WBS | Task | Duration | Start | Finish | Predecessors | Total slack | Free slack | Constraint |
| --- | --- | --- | --- | --- | --- | --- | --- | --- | --- |
| 1 | 1 | **Phase 1 Initiation Phase** | 19.12d? | 2002-11-04 | 2002-11-29 |  | 0d |  |  |
| 2 | 1.1 | **Initiating a Project** | 6d | 2002-11-04 | 2002-11-11 |  | 0d |  |  |
| 3 | 1.1.1 | Prepare Proj Plan Sect 2.0 (Project Charter and Scope Statement) | 3d | 2002-11-04 | 2002-11-06 |  | 8.88d | 3d |  |
| 4 | 1.1.2 | Prepare Proj Plan Sect 3.0 (Project Organization) | 4d | 2002-11-04 | 2002-11-07 |  | 7.88d | 2d |  |
| 5 | 1.1.3 | Identify and Evaluate Alternative Approaches | 1d | 2002-11-04 | 2002-11-04 |  | 10.88d | 5d |  |
| 6 | 1.1.4 | Start a Risk Log | 2h | 2002-11-04 | 2002-11-04 |  | 11.62d | 5.75d |  |
| 7 | 1.1.5 | Prepare Proj Plan Sect 4.2 (Initiation Phase Plan) | 6d | 2002-11-04 | 2002-11-11 |  | 0d |  |  |
| 8 | 1.2 | Gain Approval of Initiation Phase Plan and Start Project | 1h | 2002-11-12 | 2002-11-12 | 7, 6, 5, 3, 4 | 0d |  |  |
| 9 | 1.3 | WP IP-1 - Identify Requirements | 10d | 2002-11-12 | 2002-11-26 | 8 | 0d |  |  |
| 10 | 1.4 | **Planning a Project** | 12d | 2002-11-12 | 2002-11-28 | 8 | 0d |  |  |
| 11 | 1.4.1 | Review & Revise PQP | 2d | 2002-11-12 | 2002-11-14 |  | 8d |  |  |
| 12 | 1.4.2 | Prep Overall Project Plan | 7d | 2002-11-12 | 2002-11-21 |  | 3d |  |  |
| 13 | 1.4.3 | Prep Business Case | 3d | 2002-11-12 | 2002-11-15 |  | 7d |  |  |
| 14 | 1.4.4 | Setup Project File | 2d | 2002-11-12 | 2002-11-14 |  | 8d |  |  |
| 15 | 1.4.5 | Consolidate Project Plan | 2d | 2002-11-26 | 2002-11-28 | 14, 13, 12, 11, 9 | 0d |  |  |
| 16 | 1.5 | **Manage a Phase** | 18.12d | 2002-11-04 | 2002-11-28 |  | 0d |  |  |
| 17 | 1.5.1 | Executing and Controlling a Phase | 15d | 2002-11-04 | 2002-11-22 |  | 3.12d |  |  |
| 18 | 1.5.2 | Initiating and Planning a Phase | 5d | 2002-11-21 | 2002-11-28 |  | 0d |  | as late as possible |
| 19 | 1.5.3 | Closing a Phase | 2d | 2002-11-26 | 2002-11-28 |  | 0d |  | as late as possible |
| 20 | 1.6 | Gain Approval to Proceed to Next Phase | 1d? | 2002-11-28 | 2002-11-29 | 15, 16 | 0d |  |  |
| 21 | 2 | **Phase 2 Functionality Iteration 1** | 36d? | 2002-11-29 | 2003-01-20 | 1 | 0d |  |  |
| 22 | 2.1 | WP P2-1 - Specify the solution (new or revise) | 7d | 2002-11-29 | 2002-12-10 |  | 5d | 0d |  |
| 23 | 2.2 | WP P2-2 - Design the Solution | 5d | 2002-11-29 | 2002-12-06 |  | 126d |  |  |
| 24 | 2.3 | Formal Design Review (Quality Review) | 1d | 2002-12-10 | 2002-12-11 | 22 | 5d | 0d |  |
| 25 | 2.4 | WP P2-4 Development / Test Function 1 | 10d | 2002-12-11 | 2002-12-25 | 24 | 7d | 2d |  |
| 26 | 2.5 | WP P2-5 Development / Test Function 2, 3, 4 | 12d | 2002-12-11 | 2002-12-27 | 24 | 5d | 0d |  |
| 27 | 2.6 | WP P2-6 Documentation | 4d | 2002-12-11 | 2002-12-17 | 24 | 13d | 8d |  |
| 28 | 2.7 | WP P2-7 Test Functionality | 10d | 2002-12-27 | 2003-01-10 | 25, 26, 27 | 5d |  |  |

Notes:
- 9: Note: This activity is the first activity of the solution development life cycle. This work is completed in parallel with planning the project. For the definition of this activity see Identify Requirements in the Solution Development Life Cycle.

| ID | WBS | Task | Duration | Start | Finish | Predecessors | Total slack | Free slack | Constraint |
| --- | --- | --- | --- | --- | --- | --- | --- | --- | --- |
| 29 | 2.8 | **Manage a Phase** | 35d | 2002-11-29 | 2003-01-17 |  | 0d |  |  |
| 30 | 2.8.1 | Executing and Controlling a Phase | 35d | 2002-11-29 | 2003-01-17 |  | 0d |  |  |
| 31 | 2.8.2 | Initiating and Planning a Phase | 4d | 2003-01-13 | 2003-01-17 |  | 0d |  | as late as possible |
| 32 | 2.8.3 | Closing a Phase | 2d | 2003-01-15 | 2003-01-17 |  | 0d |  | as late as possible |
| 33 | 2.9 | Gain Approval to Proceed to Next Phase | 1d? | 2003-01-17 | 2003-01-20 | 29, 28 | 0d |  |  |
| 34 | 3 | **Phase 3 Functionality Iteration 2** | 31d? | 2003-01-20 | 2003-03-04 | 33 | 0d |  |  |
| 35 | 3.1 | WP P3-1 - Specify the Solution (new or revise) | 2d | 2003-01-20 | 2003-01-22 |  | 22d | 0d |  |
| 36 | 3.2 | WP P3-2 - Design the Solution | 3d | 2003-01-20 | 2003-01-23 |  | 19d | 0d |  |
| 37 | 3.3 | WP P3-4 Development / Test Function 5,6 | 7d | 2003-01-22 | 2003-01-31 | 35 | 22d |  |  |
| 38 | 3.4 | WP P3-5 Development / Test Function 7,8,9 | 9d | 2003-01-23 | 2003-02-05 | 36 | 19d |  |  |
| 39 | 3.5 | WP P3-6 Documentation | 4d | 2003-01-20 | 2003-01-24 |  | 27d |  |  |
| 40 | 3.6 | WP P3-7 Test Functionality | 10d | 2003-01-20 | 2003-02-03 |  | 20d |  |  |
| 41 | 3.7 | **Manage a Phase** | 30d | 2003-01-20 | 2003-03-03 |  | 0d |  |  |
| 42 | 3.7.1 | Executing and Controlling a Phase | 30d | 2003-01-20 | 2003-03-03 |  | 0d |  |  |
| 43 | 3.7.2 | Initiating and Planning a Phase | 10d | 2003-02-17 | 2003-03-03 |  | 0d |  | as late as possible |
| 44 | 3.7.3 | Closing a Phase | 5d | 2003-02-24 | 2003-03-03 |  | 0d |  | as late as possible |
| 45 | 3.8 | Gain Approval to Proceed to Next Phase | 1d? | 2003-03-03 | 2003-03-04 | 41, 40 | 0d |  |  |
| 46 | 4 | **Phase 4 Confirm Solution Meets Requirements** | 53d? | 2003-03-04 | 2003-05-16 | 34 | 0d |  |  |
| 47 | 4.1 | WP P4-1 Acceptance Testing 1 | 20d | 2003-03-04 | 2003-04-01 |  | 24d | 0d |  |
| 48 | 4.2 | WP P4-2 Acceptance Testing 2 | 20d | 2003-04-01 | 2003-04-29 | 47 | 24d |  |  |
| 49 | 4.3 | Evaluate feedback … | 25d? | 2003-03-04 | 2003-04-08 |  | 39d |  |  |
| 50 | 4.4 | WP P4-3 Finalise Documentation | 15d | 2003-04-01 | 2003-04-22 | 47 | 29d |  |  |
| 51 | 4.5 | WP P4-4 Test Automation | 6d | 2003-04-01 | 2003-04-09 | 47 | 38d |  |  |
| 52 | 4.6 | **Manage a Phase** | 52d? | 2003-03-04 | 2003-05-15 |  | 0d |  |  |
| 53 | 4.6.1 | Executing and Controlling a Phase | 52d? | 2003-03-04 | 2003-05-15 |  | 0d |  |  |
| 54 | 4.6.2 | Initiating and Planning a Phase | 3d | 2003-05-12 | 2003-05-15 |  | 0d |  | as late as possible |
| 55 | 4.6.3 | Closing a Phase | 2d | 2003-05-13 | 2003-05-15 |  | 0d |  | as late as possible |
| 56 | 4.7 | Gain Approval to Proceed to Next Phase | 1d | 2003-05-15 | 2003-05-16 | 52 | 0d |  |  |

| ID | WBS | Task | Duration | Start | Finish | Predecessors | Total slack | Constraint |
| --- | --- | --- | --- | --- | --- | --- | --- | --- |
| 57 | 5 | **Phase 5 Transfer Solution to the Client** | 11d | 2003-05-16 | 2003-06-02 | 56 | 0d |  |
| 58 | 5.1 | WP P5-1 Build Release | 10d | 2003-05-16 | 2003-05-30 |  | 0d | start no earlier than 2003-01-14 |
| 59 | 5.2 | **Manage a Phase** | 10d | 2003-05-16 | 2003-05-30 |  | 0d |  |
| 60 | 5.2.1 | Executing and Controlling a Phase | 10d | 2003-05-16 | 2003-05-30 |  | 0d |  |
| 61 | 5.2.2 | Closing a Project | 5d | 2003-05-23 | 2003-05-30 |  | 0d | as late as possible |
| 62 | 5.3 | Confirm Project Closed | 1d | 2003-05-30 | 2003-06-02 | 59, 58 | 0d |  |
